# 石佛营住宅小区再次调整计划(04-04-04

Schedule from MS Project, 2004-03-18 to 2005-08-12.
zhaolin

## Calendars

- 标准: Mon-Sun 08:00-12:00, 13:00-17:00.

## Schedule

| ID | WBS | Task | Duration | Start | Finish | Predecessors | Total slack | Free slack | Constraint |
| --- | --- | --- | --- | --- | --- | --- | --- | --- | --- |
| 1 | 1 | **.1.土方护坡工程** | 33d | 2004-03-18 | 2004-04-19 |  | 143d |  |  |
| 2 | 1.1 | 1.1施工准备 | 3d | 2004-03-18 | 2004-03-20 |  | 143d | 0d |  |
| 3 | 1.2 | 1.2定位放线 | 2d | 2004-03-21 | 2004-03-22 | 2 | 143d | 0d |  |
| 4 | 1.3 | 1.3机械挖土第一步 | 10d | 2004-03-23 | 2004-04-01 | 3 | 143d | 0d |  |
| 5 | 1.4 | 1.4喷锚护坡 | 3d | 2004-04-02 | 2004-04-04 | 4 | 143d | 0d |  |
| 6 | 1.5 | 1.5机械挖土第二步、护坡 | 12d | 2004-04-05 | 2004-04-16 | 5 | 143d | 0d |  |
| 7 | 1.6 | 1.6钎探验槽 | 3d | 2004-04-17 | 2004-04-19 | 6 | 143d | 0d |  |
| 8 | 2 | **2.地下结构工程** | 86d | 2004-04-20 | 2004-07-14 |  | 143d |  |  |
| 9 | 2.1 | 2.1浇筑混凝土垫层 | 3d | 2004-04-20 | 2004-04-22 | 7 | 143d | 0d |  |
| 10 | 2.2 | 2.2砌筑防水保护墙 | 2d | 2004-04-23 | 2004-04-24 | 9 | 143d | 0d |  |
| 11 | 2.3 | 2.3地下室平面防水 | 6d | 2004-04-25 | 2004-04-30 | 10 | 143d | 0d |  |
| 12 | 2.4 | 2.4豆石混凝土保护层 | 3d | 2004-05-01 | 2004-05-03 | 11 | 143d | 0d |  |
| 13 | 2.5 | 2.5底板柱基扎筋 | 12d | 2004-05-04 | 2004-05-15 | 12 | 143d | 0d |  |
| 14 | 2.6 | 2.6底板模板 | 5d | 2004-05-16 | 2004-05-20 | 13 | 143d | 0d |  |
| 15 | 2.7 | 2.7底板混凝土浇筑 | 5d | 2004-05-21 | 2004-05-25 | 14 | 143d | 0d |  |
| 16 | 2.8 | 2.8地下二层柱墙 | 10d | 2004-05-26 | 2004-06-04 | 15 | 143d | 0d |  |
| 17 | 2.9 | 2.9地下二层梁板 | 15d | 2004-06-05 | 2004-06-19 | 16 | 143d | 0d |  |
| 18 | 2.10 | 2.10地下一层柱墙 | 10d | 2004-06-20 | 2004-06-29 | 17 | 143d | 0d |  |
| 19 | 2.11 | 2.11地下一层梁板 | 15d | 2004-06-30 | 2004-07-14 | 18 | 143d | 0d |  |
| 20 | 2.12 | 2.12地下室立面防水 | 15d | 2004-06-30 | 2004-07-14 | 18 | 394d |  |  |
| 21 | 2.13 | 2.13肥槽回填土 | 15d | 2004-06-30 | 2004-07-14 | 18 | 394d |  |  |
| 22 | 2.14 | 2.14水电风预留预埋 | 60d | 2004-05-16 | 2004-07-14 | 13 | 394d |  | start no earlier than 2004-03-26 |
| 23 | 3 | **3. 1-9层结构施工** | 100d | 2004-07-15 | 2004-10-22 |  | 143d |  |  |
| 24 | 3.1 | 3.1 首层精密放线 | 3d | 2004-07-15 | 2004-07-17 | 19 | 143d | 0d |  |
| 25 | 3.2 | 3.2 首层大模板拼装 | 11d | 2004-07-18 | 2004-07-28 | 24 | 143d | 0d |  |
| 26 | 3.3 | 3.3 首层结构施工 | 10d | 2004-07-29 | 2004-08-07 | 25 | 143d | 0d |  |
| 27 | 3.4 | 3.4 2-9层结构施工 | 76d | 2004-08-08 | 2004-10-22 | 26 | 143d | 0d |  |
| 28 | 3.5 | 3.5水电预留预埋 | 100d | 2004-07-15 | 2004-10-22 | 19 | 294d |  |  |

| ID | WBS | Task | Duration | Start | Finish | Predecessors | Total slack | Free slack | Constraint |
| --- | --- | --- | --- | --- | --- | --- | --- | --- | --- |
| 29 | 4 | **4. 10-18层结构施工** | 80d | 2004-10-23 | 2005-01-10 |  | 143d |  |  |
| 30 | 4.1 | 4.1 10层精密放线 | 1d | 2004-10-23 | 2004-10-23 | 27 | 143d | 0d |  |
| 31 | 4.2 | 4.2 10-18层结构施工 | 54d | 2004-10-24 | 2004-12-16 | 30 | 143d | 0d |  |
| 32 | 4.3 | 4.3 机房层施工 | 15d | 2004-12-17 | 2004-12-31 | 31 | 143d | 0d |  |
| 33 | 4.4 | 4.4 水电预留预埋 | 70d | 2004-10-23 | 2004-12-31 | 27 | 224d |  |  |
| 34 | 4.5 | 4.6 冬期停工前整理现场 | 10d | 2005-01-01 | 2005-01-10 | 32 | 143d | 0d |  |
| 35 | 5 | **5.二次结构施工** | 157d | 2004-10-23 | 2005-03-28 |  | 137d |  |  |
| 36 | 5.1 | 5.1 6层以下二次结构 | 36d | 2004-10-23 | 2004-11-27 | 27 | 222d | 0d |  |
| 37 | 5.2 | 5.2 7-12层二次结构 | 36d | 2004-11-28 | 2005-01-02 | 36 | 222d |  |  |
| 38 | 5.3 | 5.3 水电干管、干线前期 | 72d | 2004-10-23 | 2005-01-02 | 27 | 222d |  |  |
| 39 | 5.4 | 5.4 地下车库坡道结构 | 60d | 2004-10-23 | 2004-12-21 | 27 | 234d |  | start no earlier than 2004-10-13 |
| 40 | 5.5 | 5.5 人防出入口结构 | 60d | 2004-10-28 | 2004-12-26 |  | 216d |  | start no earlier than 2004-10-28 |
| 41 | 5.6 | 5.3 13-18层二次结构 | 36d | 2005-02-21 | 2005-03-28 |  | 124d |  | start no earlier than 2005-02-21 |
| 42 | 5.7 | 5.5 水电干管、干线后期 | 36d | 2005-02-21 | 2005-03-28 |  | 124d |  | start no earlier than 2005-02-21 |
| 43 | 5.8 | 5.6 配电箱、消火栓安装 | 36d | 2005-02-21 | 2005-03-28 |  | 124d |  | start no earlier than 2005-02-21 |
| 44 | 6 | **6. 2004年冬期停工** | 43d | 2005-01-11 | 2005-02-22 |  | 143d |  |  |
| 45 | 6.1 | 6.1 2004年冬期停工 | 40d | 2005-01-11 | 2005-02-19 | 34 | 143d | 0d |  |
| 46 | 6.2 | 5.7 2005年复工准备 | 3d | 2005-02-20 | 2005-02-22 | 45 | 143d | 0d |  |
| 47 | 7 | **7.屋面工程** | 70d | 2005-02-23 | 2005-05-03 |  | 101d |  |  |
| 48 | 7.1 | 7.1屋面保温层 | 10d | 2005-02-23 | 2005-03-04 | 46 | 143d | 0d |  |
| 49 | 7.2 | 7.2屋面找坡层 | 12d | 2005-03-05 | 2005-03-16 | 48 | 143d | 0d |  |
| 50 | 7.3 | 7.3屋面找平层 | 6d | 2005-03-17 | 2005-03-22 | 49 | 143d |  | start no earlier than 2005-03-15 |
| 51 | 7.4 | 7.4防水层施工 | 12d | 2005-04-16 | 2005-04-27 |  | 88d | 0d | start no earlier than 2005-04-16 |
| 52 | 7.5 | 7.5屋面防雷工程 | 6d | 2005-04-28 | 2005-05-03 | 51 | 88d |  |  |
| 53 | 7.6 | 7.6屋面雨水排水 | 6d | 2005-04-28 | 2005-05-03 | 51 | 88d |  |  |
| 54 | 7.7 | 7.7水箱、曳引机吊装 | 3d | 2005-03-16 | 2005-03-18 |  | 134d |  | start no earlier than 2005-03-16 |

| ID | WBS | Task | Duration | Start | Finish | Predecessors | Total slack | Free slack | Constraint |
| --- | --- | --- | --- | --- | --- | --- | --- | --- | --- |
| 55 | 8 | **8.外檐保温、装修** | 352d | 2004-08-16 | 2005-08-02 |  | 10d |  |  |
| 56 | 8.1 | 8.1外脚手架搭设 | 30d | 2004-08-16 | 2004-09-14 |  | 201d | 0d | start no earlier than 2004-08-16 |
| 57 | 8.2 | 8.2外墙外保温 | 118d | 2004-09-15 | 2005-01-10 | 56 | 201d |  |  |
| 58 | 8.3 | 8.3瓦屋面 | 30d | 2005-03-16 | 2005-04-14 |  | 107d |  | start no earlier than 2005-03-16 |
| 59 | 8.4 | 8.4外檐找补薄抹灰、腻子 | 90d | 2005-03-15 | 2005-06-12 |  | 16d | 0d | start no earlier than 2005-03-15 |
| 60 | 8.5 | 8.5外檐涂料 | 24d | 2005-06-13 | 2005-07-06 | 59 | 16d | 0d | start no earlier than 2005-03-16 |
| 61 | 8.6 | 8.6外脚手架拆除 | 15d | 2005-07-07 | 2005-07-21 | 60 | 16d | 0d |  |
| 62 | 8.7 | 8.7台阶、散水、坡道 | 12d | 2005-07-22 | 2005-08-02 | 61 | 16d |  |  |
| 63 | 9 | **9.室内装修与设备安装** | 141d | 2005-03-01 | 2005-07-19 |  | 24d |  |  |
| 64 | 9.1 | **9.1地下室装修与设备安装** | 131d | 2005-03-01 | 2005-07-09 |  | 34d |  |  |
| 65 | 9.1.1 | 9.1.1立门窗框 | 8d | 2005-03-01 | 2005-03-08 |  | 21d | 0d | start no earlier than 2005-03-01 |
| 66 | 9.1.2 | 9.1.2门窗口找补抹灰 | 12d | 2005-03-09 | 2005-03-20 | 65 | 21d | 0d |  |
| 67 | 9.1.3 | 9.1.3墙面粉刷石膏 | 12d | 2005-03-21 | 2005-04-01 | 66 | 21d | 0d |  |
| 68 | 9.1.4 | 9.1.4墙面耐水腻子 | 12d | 2005-04-02 | 2005-04-13 | 67 | 21d | 0d |  |
| 69 | 9.1.5 | 9.1.5卫生间地面防水层 | 3d | 2005-04-14 | 2005-04-16 | 68 | 21d | 0d |  |
| 70 | 9.1.6 | 9.1.6卫生间地面保护层 | 3d | 2005-04-17 | 2005-04-19 | 69 | 21d | 0d |  |
| 71 | 9.1.7 | 9.1.7卫生间墙面瓷砖 | 3d | 2005-04-20 | 2005-04-22 | 70 | 21d | 0d |  |
| 72 | 9.1.8 | 9.1.8地面采暖给水管道 | 12d | 2005-04-23 | 2005-05-04 | 71 | 21d | 0d |  |
| 73 | 9.1.9 | 9.1.9细石混凝土地面 | 24d | 2005-05-05 | 2005-05-28 | 72 | 21d | 0d |  |
| 74 | 9.1.10 | 9.1.1.卫生间地面瓷砖 | 6d | 2005-05-29 | 2005-06-03 | 73 | 21d | 0d |  |
| 75 | 9.1.11 | 9.1.11走廊楼梯地面 | 12d | 2005-06-04 | 2005-06-15 | 74 | 21d | 0d |  |
| 76 | 9.1.12 | 9.1.12天棚、墙面涂料 | 12d | 2005-06-16 | 2005-06-27 | 75 | 21d | 0d |  |
| 77 | 9.1.13 | 9.1.13门扇、玻璃、油漆 | 6d | 2005-06-28 | 2005-07-03 | 76 | 21d | 0d |  |
| 78 | 9.1.14 | 9.1.14五金、洁具、灯具安装 | 6d | 2005-07-04 | 2005-07-09 | 77 | 21d |  |  |

| ID | WBS | Task | Duration | Start | Finish | Predecessors | Total slack | Free slack | Constraint |
| --- | --- | --- | --- | --- | --- | --- | --- | --- | --- |
| 79 | 9.2 | **9.2板楼室内装修与设备安装** | 83d | 2005-03-01 | 2005-05-22 |  | 82d |  |  |
| 80 | 9.2.1 | 9.2.1机房层装修 | 15d | 2005-03-01 | 2005-03-15 |  | 137d |  | start no earlier than 2005-03-01 |
| 81 | 9.2.2 | 9.2.2立门窗框 | 18d | 2005-03-01 | 2005-03-18 |  | 83d | 0d | start no earlier than 2005-03-01 |
| 82 | 9.2.3 | 9.2.3门窗口找补抹灰 | 18d | 2005-03-10 | 2005-03-27 |  | 95d | 0d | start no earlier than 2005-03-10 |
| 83 | 9.2.4 | 9.2.4墙面粉刷石膏 | 30d | 2005-03-19 | 2005-04-17 | 81 | 86d | 0d |  |
| 84 | 9.2.5 | 9.2.5墙面耐水腻子 | 30d | 2005-03-28 | 2005-04-26 | 82 | 95d |  |  |
| 85 | 9.2.6 | 9.2.6卫生间地面防水层 | 18d | 2005-03-01 | 2005-03-18 |  | 116d | 0d | start no earlier than 2005-03-01 |
| 86 | 9.2.7 | 9.2.7卫生间地面保护层 | 18d | 2005-03-19 | 2005-04-05 | 85 | 116d |  |  |
| 87 | 9.2.8 | 9.2.8卫生间墙面瓷砖 | 30d | 2005-04-16 | 2005-05-15 |  | 76d |  | start no earlier than 2005-04-16 |
| 88 | 9.2.9 | 9.2.9地面采暖给水管道 | 30d | 2005-03-01 | 2005-03-30 |  | 122d |  | start no earlier than 2005-03-01 |
| 89 | 9.2.10 | 9.2.10居室地面 | 30d | 2005-03-08 | 2005-04-06 |  | 79d | 0d | start no earlier than 2005-03-08 |
| 90 | 9.2.11 | 9.2.11卫生间地面瓷砖 | 18d | 2005-04-07 | 2005-04-24 | 89 | 79d | 0d |  |
| 91 | 9.2.12 | 9.2.12走廊楼梯地面 | 18d | 2005-04-25 | 2005-05-12 | 90 | 79d |  |  |
| 92 | 9.2.13 | 9.2.13天棚、墙面涂料 | 18d | 2005-04-18 | 2005-05-05 | 83 | 86d |  |  |
| 93 | 9.2.14 | 9.2.14门扇、玻璃、油漆 | 51d | 2005-03-19 | 2005-05-08 | 81 | 83d |  |  |
| 94 | 9.2.15 | 9.2.15五金、洁具、灯具安装 | 15d | 2005-05-08 | 2005-05-22 |  | 69d |  | start no earlier than 2005-05-08 |
| 95 | 9.3 | **9.3 塔楼室内装修与设备安装** | 141d | 2005-03-01 | 2005-07-19 |  | 24d |  |  |
| 96 | 9.3.1 | 9.3.1机房层装修 | 30d | 2005-03-01 | 2005-03-30 |  | 12d | 0d | start no earlier than 2005-03-01 |
| 97 | 9.3.2 | 9.3.2立门窗框 | 36d | 2005-03-01 | 2005-04-05 |  | 11d | 0d | start no earlier than 2005-03-01 |
| 98 | 9.3.3 | 9.3.3门窗口找补抹灰 | 36d | 2005-03-10 | 2005-04-14 |  | 47d | 0d | start no earlier than 2005-03-10 |
| 99 | 9.3.4 | 9.3.4墙面粉刷石膏 | 60d | 2005-04-06 | 2005-06-04 | 97 | 20d | 0d |  |
| 100 | 9.3.5 | 9.3.5墙面耐水腻子 | 60d | 2005-04-15 | 2005-06-13 | 98 | 47d |  |  |
| 101 | 9.3.6 | 9.3.6卫生间地面防水层 | 36d | 2005-03-01 | 2005-04-05 |  | 80d | 0d | start no earlier than 2005-03-01 |
| 102 | 9.3.7 | 9.3.7卫生间地面保护层 | 36d | 2005-04-06 | 2005-05-11 | 101 | 80d |  |  |
| 103 | 9.3.8 | 9.3.8卫生间墙面瓷砖 | 60d | 2005-04-16 | 2005-06-14 |  | 46d |  | start no earlier than 2005-04-16 |
| 104 | 9.3.9 | 9.3.9地面采暖给水管道 | 60d | 2005-03-01 | 2005-04-29 |  | 92d |  | start no earlier than 2005-03-01 |
| 105 | 9.3.10 | 9.3.10居室地面 | 60d | 2005-03-08 | 2005-05-06 |  | 13d | 0d | start no earlier than 2005-03-08 |
| 106 | 9.3.11 | 9.3.11卫生间地面瓷砖 | 36d | 2005-05-07 | 2005-06-11 | 105 | 13d | 0d |  |
| 107 | 9.3.12 | 9.3.12走廊楼梯地面 | 36d | 2005-06-12 | 2005-07-17 | 106 | 13d |  |  |
| 108 | 9.3.13 | 9.3.13天棚、墙面涂料 | 36d | 2005-06-05 | 2005-07-10 | 99 | 20d |  |  |
| 109 | 9.3.14 | 9.3.14门扇、玻璃、油漆 | 105d | 2005-04-06 | 2005-07-19 | 97 | 11d |  |  |
| 110 | 9.3.15 | 9.3.15五金、洁具、灯具安装 | 30d | 2005-06-20 | 2005-07-19 |  | 11d |  | start no earlier than 2005-06-20 |

| ID | WBS | Task | Type | Duration | Start | Finish | Predecessors | Total slack | Free slack | Constraint |
| --- | --- | --- | --- | --- | --- | --- | --- | --- | --- | --- |
| 111 | 10 | **10.电梯安装** |  | 110d | 2005-03-31 | 2005-07-18 |  | 25d |  |  |
| 112 | 10.1 | 10.1 塔楼电梯安装 |  | 80d | 2005-03-31 | 2005-06-18 | 96 | 42d |  |  |
| 113 | 10.2 | 10.2 板楼电梯安装 |  | 110d | 2005-03-31 | 2005-07-18 | 96 | 12d |  |  |
| 114 | 11 | **11.人防通风工程** |  | 48d | 2005-03-01 | 2005-04-17 |  | 117d |  |  |
| 115 | 11.1 | 11.1 通风管道安装 |  | 36d | 2005-03-01 | 2005-04-05 |  | 104d | 0d | start no earlier than 2005-03-01 |
| 116 | 11.2 | 11.2 通风设备安装 |  | 12d | 2005-04-06 | 2005-04-17 | 115 | 104d |  |  |
| 117 | 12 | **12 收尾、清理、调试、验收** |  | 341d | 2004-09-06 | 2005-08-12 |  | 0d |  |  |
| 118 | 12.1 | 12.1 板楼收尾、清理 |  | 20d | 2005-06-01 | 2005-06-20 |  | 29d | 0d | start no earlier than 2005-06-01 |
| 119 | 12.2 | 12.2 塔楼收尾、清理 |  | 30d | 2005-06-21 | 2005-07-20 | 118 | 29d |  |  |
| 120 | 12.3 | 12.3 管道试压、保温、调试 |  | 18d | 2005-07-16 | 2005-08-02 |  | 16d | 0d | start no earlier than 2005-07-16 |
| 121 | 12.4 | 12.4 设备专业试运行 |  | 6d | 2005-08-01 | 2005-08-06 |  | 12d |  | start no earlier than 2005-08-01 |
| 122 | 12.5 | 12.5 电气专业调试、试运行 |  | 6d | 2005-08-01 | 2005-08-06 |  | 12d |  | start no earlier than 2005-08-01 |
| 123 | 12.6 | 12.6 主楼地下结构工程验收 | milestone | 0d | 2004-09-06 | 2004-09-06 |  | 347d |  | start no earlier than 2004-09-06 |
| 124 | 12.7 | 12.7 主体结构工程验收 | milestone | 0d | 2005-03-06 | 2005-03-06 | 125 | 147d |  |  |
| 125 | 12.8 | 12.8 车库、坡道结构验收 | milestone | 0d | 2005-03-06 | 2005-03-06 |  | 166d | 0d | start no earlier than 2005-03-06 |
| 126 | 12.9 | 12.9 城市建设档案预验收 | milestone | 0d | 2005-07-30 | 2005-07-30 |  | 14d |  | start no earlier than 2005-07-30 |
| 127 | 12.10 | 12.10 规划部门验收 | milestone | 0d | 2005-08-02 | 2005-08-02 |  | 11d |  | start no earlier than 2005-08-02 |
| 128 | 12.11 | 12.11 人防工程验收 | milestone | 0d | 2005-08-04 | 2005-08-04 |  | 9d |  | start no earlier than 2005-08-04 |
| 129 | 12.12 | 12.12 单位工程预验收 | milestone | 0d | 2005-08-06 | 2005-08-06 |  | 0d |  | start no earlier than 2005-08-06 |
| 130 | 12.13 | 12.13 竣工备案 |  | 7d | 2005-08-06 | 2005-08-12 | 129 | 0d |  |  |
